Schedule from MS Project, 2024-02-20 to 2024-11-20, status date 2024-05-14, A marks actual dates.

## Calendars

- Standard: Mon-Sun 08:00-12:00, 13:00-17:00.

## Schedule

| ID | WBS | Task | Duration | Start | Finish | Predecessors | Complete | Remaining | Baseline start | Baseline finish | Baseline duration | Total slack | Free slack |
| --- | --- | --- | --- | --- | --- | --- | --- | --- | --- | --- | --- | --- | --- |
| 1 | 1 | **RU Petroelectric** | 275d | 2024-02-20 A | 2024-11-20 |  | 30% | 191.62d | 2024-02-20 | 2024-11-20 | 275d | 0d |  |
| 2 | 1.1 | **ENG** | 275d | 2024-02-20 A | 2024-11-20 |  | 53% | 130.53d | 2024-02-20 | 2024-11-20 | 275d | 0d |  |
| 3 | 1.1.1 | **General** | 275d | 2024-02-20 A | 2024-11-20 |  | 41% | 162.5d | 2024-02-20 | 2024-11-20 | 275d | 0d |  |
| 4 | 1.1.1.1 | Project Schedule | 15d | 2024-03-06 A | 2024-03-20 A | 5 | 100% |  | 2024-03-06 | 2024-03-20 | 15d |  |  |
| 5 | 1.1.1.2 | Vendor Document & Index Schedule (VDIS) | 15d | 2024-02-20 A | 2024-03-05 A |  | 100% |  | 2024-02-20 | 2024-03-05 | 15d |  |  |
| 6 | 1.1.1.3 | Final data book Index | 15d | 2024-08-03 | 2024-08-17 | 5FS+150d |  |  | 2024-08-03 | 2024-08-17 | 15d | 95d |  |
| 7 | 1.1.1.4 | Final data book | 5d | 2024-11-16 | 2024-11-20 | 78 |  |  | 2024-11-16 | 2024-11-20 | 5d | 0d |  |
| 8 | 1.1.1.5 | Packing, Marking & Shipping Procedure | 15d | 2024-08-03 | 2024-08-17 | 5FS+150d |  |  | 2024-08-03 | 2024-08-17 | 15d | 95d |  |
| 9 | 1.1.1.6 | Sub-Vendor List | 15d | 2024-03-06 A | 2024-03-20 A | 5 | 100% |  | 2024-03-06 | 2024-03-20 | 15d |  |  |
| 10 | 1.1.1.7 | Spare Part List for Commissioning & Start-up and Two Years Operation | 15d | 2024-06-04 | 2024-06-18 | 5FS+90d |  |  | 2024-06-04 | 2024-06-18 | 15d | 155d |  |
| 11 | 1.1.1.8 | Special Tools List | 15d | 2024-05-20 | 2024-06-03 | 5FS+75d |  |  | 2024-05-20 | 2024-06-03 | 15d | 170d |  |
| 12 | 1.1.2 | **Process** | 62d | 2024-04-10 A | 2024-06-10 |  | 48% | 32.38d | 2024-04-10 | 2024-06-10 | 62d | 163d |  |
| 13 | 1.1.2.1 | Process Flow Diagram (PFD) | 30d | 2024-04-10 A | 2024-05-09 A | 20FS+15d | 100% |  | 2024-04-10 | 2024-05-09 | 30d |  |  |
| 14 | 1.1.2.2 | Piping And Instrumentation Diagram (P&ID) | 30d | 2024-05-12 A | 2024-06-10 | 13FS+2d | 10% | 27d | 2024-05-12 | 2024-06-10 | 30d | 148d | 0d |
| 15 | 1.1.2.3 | Utility Consumption List including Electrical Load List | 15d | 2024-05-10 A | 2024-05-24 | 13 | 33% | 10d | 2024-05-10 | 2024-05-24 | 15d | 180d |  |
| 16 | 1.1.2.4 | Lubricant List/Grease List | 15d | 2024-05-10 A | 2024-05-24 | 13 | 33% | 10d | 2024-05-10 | 2024-05-24 | 15d | 180d |  |
| 17 | 1.1.3 | **Civil** | 15d | 2024-06-11 | 2024-06-25 |  |  |  | 2024-06-11 | 2024-06-25 | 15d | 148d |  |
| 18 | 1.1.3.1 | Skid Foundation Plan | 15d | 2024-06-11 | 2024-06-25 | 14 |  |  | 2024-06-11 | 2024-06-25 | 15d | 148d |  |
| 19 | 1.1.4 | **Mechanical** | 80d | 2024-03-06 A | 2024-05-24 |  | 90% | 8d | 2024-03-06 | 2024-05-24 | 80d | 180d |  |
| 20 | 1.1.4.1 | Package / Compressor Data Sheet | 20d | 2024-03-06 A | 2024-03-25 A | 5 | 100% |  | 2024-03-06 | 2024-03-25 | 20d |  |  |
| 21 | 1.1.4.2 | Compressor Package Outline Drawing | 30d | 2024-03-26 A | 2024-04-24 A | 20 | 100% |  | 2024-03-26 | 2024-04-24 | 30d |  |  |
| 22 | 1.1.4.3 | Oil Heater Data Sheet and Drawing | 15d | 2024-05-10 A | 2024-05-24 | 13 | 33% | 10d | 2024-05-10 | 2024-05-24 | 15d | 180d |  |
| 23 | 1.1.4.4 | Condenser Data Sheet | 20d | 2024-03-06 A | 2024-03-25 A | 5 | 100% |  | 2024-03-06 | 2024-03-25 | 20d |  |  |
| 24 | 1.1.4.5 | Condenser Outline Drawing | 20d | 2024-03-26 A | 2024-04-14 A | 23 | 100% |  | 2024-03-26 | 2024-04-14 | 20d |  |  |
| 25 | 1.1.4.6 | Mechanical calculation for Condenser | 20d | 2024-03-26 A | 2024-04-14 A | 23 | 100% |  | 2024-03-26 | 2024-04-14 | 20d |  |  |
| 26 | 1.1.4.7 | Chiller (Evaporator) Data Sheet | 20d | 2024-03-06 A | 2024-03-25 A | 5 | 100% |  | 2024-03-06 | 2024-03-25 | 20d |  |  |
| 27 | 1.1.4.8 | Chiller (Evaporator) Outline Drawing | 20d | 2024-03-26 A | 2024-04-14 A | 26 | 100% |  | 2024-03-26 | 2024-04-14 | 20d |  |  |
| 28 | 1.1.4.9 | Chiller (Evaporator) Mechanical calculation | 20d | 2024-03-26 A | 2024-04-14 A | 26 | 100% |  | 2024-03-26 | 2024-04-14 | 20d |  |  |
| 29 | 1.1.4.10 | Filter Dryer Data Sheet | 15d | 2024-05-10 A | 2024-05-24 | 13 | 33% | 10d | 2024-05-10 | 2024-05-24 | 15d | 180d |  |

| ID | WBS | Task | Duration | Start | Finish | Predecessors | Complete | Remaining | Baseline start | Baseline finish | Baseline duration | Total slack | Free slack | Constraint |
| --- | --- | --- | --- | --- | --- | --- | --- | --- | --- | --- | --- | --- | --- | --- |
| 30 | 1.1.5 | **Piping** | 60d | 2024-05-10 A | 2024-07-08 |  | 8% | 55d | 2024-05-10 | 2024-07-08 | 60d | 135d |  |  |
| 31 | 1.1.5.1 | General Arrangement Drawing | 30d | 2024-05-10 A | 2024-06-08 | 13 | 17% | 25d | 2024-05-10 | 2024-06-08 | 30d | 135d | 0d |  |
| 32 | 1.1.5.2 | 3D Model | 30d | 2024-06-09 | 2024-07-08 | 31 |  |  | 2024-06-09 | 2024-07-08 | 30d | 135d |  |  |
| 33 | 1.1.6 | **QUALITY CONTROL** | 115d | 2024-03-06 A | 2024-06-28 |  | 33% | 76.67d | 2024-03-06 | 2024-06-28 | 115d | 145d |  |  |
| 34 | 1.1.6.1 | Inspection And Test (ITP) | 15d | 2024-03-06 A | 2024-03-20 A | 5 | 100% |  | 2024-03-06 | 2024-03-20 | 15d |  |  | start no earlier than 2023-06-20 |
| 35 | 1.1.6.2 | Painting Procedure | 15d | 2024-05-10 A | 2024-05-24 | 13 | 33% | 10d | 2024-05-10 | 2024-05-24 | 15d | 180d |  |  |
| 36 | 1.1.6.3 | Compressor Test Procedure | 15d | 2024-05-10 A | 2024-05-24 | 13 | 33% | 10d | 2024-05-10 | 2024-05-24 | 15d | 180d |  |  |
| 37 | 1.1.6.4 | Test Procedure For Air Condenser and Chiller | 15d | 2024-05-15 | 2024-05-29 | 25, 28FS+30d |  |  | 2024-05-15 | 2024-05-29 | 15d | 175d |  |  |
| 38 | 1.1.6.5 | Weld book WPS/PQR/Weld Map For Air Condenser and Chiller | 15d | 2024-06-14 | 2024-06-28 | 25, 28FS+60d |  |  | 2024-06-14 | 2024-06-28 | 15d | 145d |  | start no earlier than 2024-03-01 |
| 39 | 1.1.7 | **Piping** | 47d | 2024-05-10 A | 2024-06-25 |  | 29% | 33.29d | 2024-05-10 | 2024-06-25 | 47d | 148d |  |  |
| 40 | 1.1.7.1 | Cause & Effect Diagram | 15d | 2024-06-11 | 2024-06-25 | 14 |  |  | 2024-06-11 | 2024-06-25 | 15d | 148d |  |  |
| 41 | 1.1.7.2 | Control Valve Data Sheet | 15d | 2024-05-10 A | 2024-05-24 | 13 | 33% | 10d | 2024-05-10 | 2024-05-24 | 15d | 180d |  |  |
| 42 | 1.1.7.3 | Instrument Data Sheet | 15d | 2024-05-10 A | 2024-05-24 | 13 | 33% | 10d | 2024-05-10 | 2024-05-24 | 15d | 180d |  |  |
| 43 | 1.1.7.4 | Local Panel and Junction Box Wiring Diagrams | 15d | 2024-05-10 A | 2024-05-24 | 13 | 33% | 10d | 2024-05-10 | 2024-05-24 | 15d | 180d |  |  |
| 44 | 1.1.7.5 | I/O-list | 15d | 2024-05-10 A | 2024-05-24 | 13 | 33% | 10d | 2024-05-10 | 2024-05-24 | 15d | 180d |  | start no earlier than 2023-06-14 |
| 45 | 1.1.7.6 | ON/OFF-Solenoid Valve Data Sheet | 15d | 2024-05-10 A | 2024-05-24 | 13 | 33% | 10d | 2024-05-10 | 2024-05-24 | 15d | 180d |  |  |
| 46 | 1.1.7.7 | Safety / Relief Valve Data Sheet | 15d | 2024-05-10 A | 2024-05-24 | 13 | 33% | 10d | 2024-05-10 | 2024-05-24 | 15d | 180d |  |  |
| 47 | 1.1.7.8 | PLC Layout Drawing | 15d | 2024-05-10 A | 2024-05-24 | 13 | 33% | 10d | 2024-05-10 | 2024-05-24 | 15d | 180d |  |  |
| 48 | 1.1.8 | **Electrical** | 20d | 2024-03-26 A | 2024-04-14 A |  | 100% |  | 2024-03-26 | 2024-04-14 | 20d |  |  |  |
| 49 | 1.1.8.1 | Compressor Motor Data Sheet & Drawing | 20d | 2024-03-26 A | 2024-04-14 A | 5FS+20d | 100% |  | 2024-03-26 | 2024-04-14 | 20d |  |  |  |
| 50 | 1.1.8.2 | Oil pump Motor Datasheet & Drawing | 20d | 2024-03-26 A | 2024-04-14 A | 5FS+20d | 100% |  | 2024-03-26 | 2024-04-14 | 20d |  |  |  |
| 51 | 1.2 | **Supply** | 95d | 2024-03-06 A | 2024-06-08 |  | 68% | 30.4d | 2024-03-06 | 2024-06-08 | 95d | 0d |  |  |
| 52 | 1.2.1 | **Condensor** | 15d | 2024-04-25 A | 2024-05-09 A |  | 100% |  | 2024-04-25 | 2024-05-09 | 15d |  |  |  |
| 53 | 1.2.1.1 | PO Placement of Condensor | 15d | 2024-04-25 A | 2024-05-09 A | 23FS+30d | 100% |  | 2024-04-25 | 2024-05-09 | 15d |  |  | start no earlier than 2023-07-01 |

| ID | WBS | Task | Type | Duration | Start | Finish | Predecessors | Complete | Remaining | Baseline start | Baseline finish | Baseline duration | Total slack | Free slack | Constraint |
| --- | --- | --- | --- | --- | --- | --- | --- | --- | --- | --- | --- | --- | --- | --- | --- |
| 54 | 1.2.2 | **Evaporator** |  | 15d | 2024-04-25 A | 2024-05-09 A |  | 100% |  | 2024-04-25 | 2024-05-09 | 15d |  |  |  |
| 55 | 1.2.2.1 | PO Placement of Evaporator |  | 15d | 2024-04-25 A | 2024-05-09 A | 26FS+30d | 100% |  | 2024-04-25 | 2024-05-09 | 15d |  |  |  |
| 56 | 1.2.3 | **Compressor Skid** |  | 15d | 2024-03-06 A | 2024-03-20 A |  | 100% |  | 2024-03-06 | 2024-03-20 | 15d |  |  |  |
| 57 | 1.2.3.1 | PO Placement of Compressor Skid |  | 15d | 2024-03-06 A | 2024-03-20 A | 5 | 100% |  | 2024-03-06 | 2024-03-20 | 15d |  |  |  |
| 58 | 1.2.4 | **PLC** |  | 20d | 2024-05-10 A | 2024-05-29 |  | 25% | 15d | 2024-05-10 | 2024-05-29 | 20d | 10d |  |  |
| 59 | 1.2.4.1 | PO Placement of PLC |  | 20d | 2024-05-10 A | 2024-05-29 | 13 | 25% | 15d | 2024-05-10 | 2024-05-29 | 20d | 10d | 0d |  |
| 60 | 1.2.5 | **Valves& Electrical & other Instruments** |  | 30d | 2024-05-10 A | 2024-06-08 |  | 17% | 25d | 2024-05-10 | 2024-06-08 | 30d | 0d |  |  |
| 61 | 1.2.5.1 | PO Placement of Valves& Other |  | 30d | 2024-05-10 A | 2024-06-08 | 13 | 17% | 25d | 2024-05-10 | 2024-06-08 | 30d | 0d |  |  |
| 62 | 1.2.6 | **Electro Motor** |  | 30d | 2024-04-15 A | 2024-05-14 A |  | 100% |  | 2024-04-15 | 2024-05-14 | 30d |  |  |  |
| 63 | 1.2.6.1 | PO Placement of Electro Motor |  | 30d | 2024-04-15 A | 2024-05-14 A | 49, 50 | 100% |  | 2024-04-15 | 2024-05-14 | 30d |  |  |  |
| 64 | 1.3 | **Manufacturing** |  | 240d | 2024-03-21 A | 2024-11-15 |  | 7% | 222.27d | 2024-03-21 | 2024-11-15 | 240d | 0d |  |  |
| 65 | 1.3.1 | **Condensor** |  | 150d | 2024-05-10 A | 2024-10-06 |  | 3% | 145d | 2024-05-10 | 2024-10-06 | 150d | 0d |  |  |
| 66 | 1.3.1.1 | Manufacturing of Condensor |  | 150d | 2024-05-10 A | 2024-10-06 | 53 | 3% | 145d | 2024-05-10 | 2024-10-06 | 150d | 0d |  | finish no earlier than 2024-06-15 |
| 67 | 1.3.2 | **Evaporator** |  | 120d | 2024-05-10 A | 2024-09-06 |  | 3% | 116d | 2024-05-10 | 2024-09-06 | 120d |  |  |  |
| 68 | 1.3.2.1 | Manufacturing of Evaporator |  | 150d | 2024-05-10 A | 2024-10-06 | 55 | 3% | 145d | 2024-05-10 | 2024-10-06 | 150d | 0d |  | finish no earlier than 2024-06-15 |
| 69 | 1.3.3 | **Compressor Skid** |  | 180d | 2024-03-21 A | 2024-09-16 |  | 31% | 125d | 2024-03-21 | 2024-09-16 | 180d | 20d |  |  |
| 70 | 1.3.3.1 | Manufacturing Compressor |  | 180d | 2024-03-21 A | 2024-09-16 | 57 | 31% | 125d | 2024-03-21 | 2024-09-16 | 180d | 20d |  |  |
| 71 | 1.3.4 | **PLC** |  | 120d | 2024-05-30 | 2024-09-26 |  |  |  | 2024-05-30 | 2024-09-26 | 120d | 10d |  |  |
| 72 | 1.3.4.1 | Manufacturing PLC |  | 120d | 2024-05-30 | 2024-09-26 | 59 |  |  | 2024-05-30 | 2024-09-26 | 120d | 10d |  | finish no earlier than 2024-07-15 |
| 73 | 1.3.5 | **Valves& Electrical & other Instruments** |  | 120d | 2024-06-09 | 2024-10-06 |  |  |  | 2024-06-09 | 2024-10-06 | 120d | 0d |  |  |
| 74 | 1.3.5.1 | Manufacturing Valves& Other |  | 120d | 2024-06-09 | 2024-10-06 | 61 |  |  | 2024-06-09 | 2024-10-06 | 120d | 0d |  | finish no earlier than 2024-05-25 |
| 75 | 1.3.6 | **Electro Motor** |  | 120d | 2024-05-15 | 2024-09-11 |  |  |  | 2024-05-15 | 2024-09-11 | 120d | 25d |  |  |
| 76 | 1.3.6.1 | Manufacturing Electro Motor |  | 120d | 2024-05-15 | 2024-09-11 | 63 |  |  | 2024-05-15 | 2024-09-11 | 120d | 25d |  |  |
| 77 | 1.3.7 | **Manufacturing and assembly** |  | 40d | 2024-10-07 | 2024-11-15 |  |  |  | 2024-10-07 | 2024-11-15 | 40d | 0d |  |  |
| 78 | 1.3.7.1 | Manufacturing and assembly package |  | 40d | 2024-10-07 | 2024-11-15 | 66, 68, 70, 72, 74, 76 |  |  | 2024-10-07 | 2024-11-15 | 40d | 0d |  |  |
| 79 | 1.4 | Final Inspection |  | 5d | 2024-11-16 | 2024-11-20 | 78 |  |  | 2024-11-16 | 2024-11-20 | 5d | 0d |  |  |
| 80 | 1.5 | Final Book |  | 5d | 2024-11-16 | 2024-11-20 | 78 |  |  | 2024-11-16 | 2024-11-20 | 5d | 0d |  |  |
| 81 | 1.6 | Finish | milestone | 0d | 2024-11-20 | 2024-11-20 | 80 |  |  | 2024-11-20 | 2024-11-20 | 0d | 0d |  |  |
